# 13garaaz2000

Schedule from MS Project, 2001-03-30 to 2001-05-03.
AS Audentes

## Calendars

- Standard: Mon-Fri 08:00-12:00, 13:00-17:00; Sat-Sun off.

## Resources

| Resource |
| --- |
| MT |
| OT |

## Schedule

| ID | Task | Type | Duration | Start | Finish | Predecessors | Total slack | Free slack | Resources | Work |
| --- | --- | --- | --- | --- | --- | --- | --- | --- | --- | --- |
| 1 | Algus | milestone | 0d | 2001-03-30 | 2001-03-30 |  | 0d |  |  |  |
| 2 | Vundamendi augu kaevamine |  | 4d | 2001-03-30 | 2001-04-04 | 1 | 0d |  | MT | 32h |
| 3 | Vundam. valu + kuivamine |  | 2d | 2001-04-05 | 2001-04-06 | 2 | 0d |  | MT | 16h |
| 4 | Ukseraami valmistamine |  | 1d | 2001-03-30 | 2001-03-30 | 1 | 4d | 0d | OT | 8h |
| 5 | Ukseraami paigaldamine |  | 1d | 2001-04-02 | 2001-04-02 | 4 | 4d |  | OT | 8h |
| 6 | Müüride ladumine |  | 10d | 2001-04-09 | 2001-04-20 | 3, 5 | 0d |  | OT; MT | 160h |
| 7 | Katuse silluse paigaldamine |  | 1d | 2001-04-23 | 2001-04-23 | 6 | 0d |  | OT; MT | 16h |
| 8 | Katuselaudade saagimine |  | 1d | 2001-04-03 | 2001-04-03 | 1 | 14d |  | OT | 8h |
| 9 | Katuselaudade paigaldamine |  | 2d | 2001-04-24 | 2001-04-25 | 7, 8 | 0d |  | OT; MT | 32h |
| 10 | Katuseplaatide paigaldamine |  | 1d | 2001-04-26 | 2001-04-26 | 9 | 0d |  | OT | 8h |
| 11 | Katuse tihendamine |  | 2d | 2001-05-01 | 2001-05-02 | 10 | 1d |  | OT | 16h |
| 12 | Katuse otsalaudade löömine |  | 1d | 2001-04-30 | 2001-04-30 | 10 | 0d |  | OT | 8h |
| 13 | Tuulekarbi valmistamine |  | 2d | 2001-04-27 | 2001-04-30 | 10 | 0d |  | OT; MT | 32h |
| 14 | Kuivenduskraavi kaevamine |  | 2d | 2001-04-25 | 2001-04-26 | 1 | 0d |  | MT | 16h |
| 15 | Kuivendustorude paigaldamine |  | 1d | 2001-04-27 | 2001-04-27 | 14 | 0d |  | OT; MT | 16h |
| 16 | Vihmaveetorude paigaldamine |  | 1d | 2001-05-03 | 2001-05-03 | 15, 10 | 0d |  | OT | 8h |
| 17 | Kuivenduskraavi kinniajamine |  | 1d | 2001-05-01 | 2001-05-01 | 15 | 2d |  | MT | 8h |
| 18 | Põranda täitmine |  | 2d | 2001-04-20 | 2001-04-23 | 3 | 2d | 0d | MT | 16h |
| 19 | Põranda silumine |  | 1d | 2001-04-25 | 2001-04-25 | 18 | 2d | 0d | OT | 8h |
| 20 | Uste valmistamine |  | 3d | 2001-04-04 | 2001-04-06 | 1 | 15d | 13d | OT | 24h |
| 21 | Uste riputamine |  | 1d | 2001-04-26 | 2001-04-26 | 20, 6, 19 | 2d |  | OT; MT | 16h |
| 22 | Puitdetailide värvimine |  | 3d | 2001-05-01 | 2001-05-03 | 12, 13, 21 | 0d |  | OT | 24h |
| 23 | Lõpp | milestone | 0d | 2001-05-03 | 2001-05-03 | 22, 17, 11, 16 | 0d |  |  |  |
